# Customer Care Website Implementation

Schedule from MS Project, 2012-04-02 to 2012-12-07, costs in $.

## Calendars

- Standard: Mon-Fri 08:00-12:00, 13:00-17:00; Sat-Sun off.

## Resources

| Resource | Rate |
| --- | --- |
| Project Manager | 40 |
| Customer Care Manager | 40 |
| Business Analyst | 30 |
| Software Architect | 30 |
| Software Developer - 1 | 20 |
| Software Developer - 2 | 20 |
| Software Tester | 20 |
| Project Sponsor |  |

## Schedule

| ID | WBS | Task | Type | Duration | Start | Finish | Predecessors | Total slack | Resources | Work | Cost |
| --- | --- | --- | --- | --- | --- | --- | --- | --- | --- | --- | --- |
| 1 | 1 | **Customer Care Website Implementation** |  | 180d | 2012-04-02 | 2012-12-07 |  | 0d |  | 3064h | 80,720 |
| 2 | 1.1 | **Project Initiation and Planning** |  | 15d | 2012-04-02 | 2012-04-20 |  | 0d |  | 216h | 7,360 |
| 3 | 1.1.1 | Initial meeting with project sponsor |  | 1d | 2012-04-02 | 2012-04-02 |  | 0d | Customer Care Manager; Project Manager; Project Sponsor | 24h | 640 |
| 4 | 1.1.2 | Identify user groups |  | 3d | 2012-04-03 | 2012-04-05 | 3 | 0d | Project Manager; Customer Care Manager | 48h | 1,920 |
| 5 | 1.1.3 | Plan for resources and people required |  | 5d | 2012-04-06 | 2012-04-12 | 4 | 0d | Project Manager | 40h | 1,600 |
| 6 | 1.1.4 | Create annd Share project plan with team |  | 5d | 2012-04-13 | 2012-04-19 | 5 | 0d | Project Manager | 40h | 1,600 |
| 7 | 1.1.5 | Project Kickoff Meeting |  | 1d | 2012-04-20 | 2012-04-20 | 6 | 0d | Project Manager; Customer Care Manager; Business Analyst; Project Sponsor; Software Architect; Software Developer - 1; Software Developer - 2; Software Tester | 64h | 1,600 |
| 8 | 1.2 | **Requirements Analysis** |  | 11d | 2012-04-23 | 2012-05-07 |  | 0d |  | 192h | 5,280 |
| 9 | 1.2.1 | Requirements meeting with users |  | 10d | 2012-04-23 | 2012-05-04 | 7 | 155d | Business Analyst | 80h | 2,400 |
| 10 | 1.2.2 | Requirements workshop |  | 3d | 2012-04-23 | 2012-04-25 | 7 | 0d | Business Analyst | 24h | 720 |
| 11 | 1.2.3 | Document requirements and submit |  | 5d | 2012-04-26 | 2012-05-02 | 10 | 0d | Business Analyst | 40h | 1,200 |
| 12 | 1.2.4 | Review of requirements |  | 3d | 2012-05-03 | 2012-05-07 | 11 | 0d | Customer Care Manager; Project Sponsor | 48h | 960 |
| 13 | 1.2.5 | Requirements signoff | milestone | 0d | 2012-05-07 | 2012-05-07 | 12 | 0d | Customer Care Manager; Project Sponsor |  |  |
| 14 | 1.3 | **System Design** |  | 11d | 2012-05-08 | 2012-05-22 |  | 0d |  | 200h | 6,000 |
| 15 | 1.3.1 | Logical design of system |  | 5d | 2012-05-08 | 2012-05-14 | 13 | 0d | Business Analyst; Software Architect | 80h | 2,400 |
| 16 | 1.3.2 | Physical design of system |  | 5d | 2012-05-15 | 2012-05-21 | 15 | 0d | Software Architect | 40h | 1,200 |
| 17 | 1.3.3 | Validate and review design document |  | 3d | 2012-05-15 | 2012-05-17 | 15 | 2d | Business Analyst; Project Manager; Software Developer - 1 | 72h | 2,160 |
| 18 | 1.3.4 | Discussion of design with team |  | 1d | 2012-05-22 | 2012-05-22 | 17, 16 | 0d | Software Architect | 8h | 240 |
| 19 | 1.3.5 | Design approval and signoff | milestone | 0d | 2012-05-22 | 2012-05-22 | 18 | 0d | Project Sponsor |  |  |
| 20 | 1.4 | **Coding and Development** |  | 80d | 2012-05-23 | 2012-09-11 |  | 0d |  | 1600h | 34,000 |
| 21 | 1.4.1 | Meeting for understanding and clarifying requirements |  | 5d | 2012-05-23 | 2012-05-29 | 19 | 0d | Business Analyst; Customer Care Manager; Software Developer - 1; Software Developer - 2; Software Tester | 200h | 5,200 |
| 22 | 1.4.2 | Coding and development |  | 40d | 2012-05-30 | 2012-07-24 | 21 | 0d | Software Developer - 1; Software Developer - 2 | 640h | 12,800 |
| 23 | 1.4.3 | System testing |  | 20d | 2012-07-25 | 2012-08-21 | 22, 21 | 0d | Software Tester | 160h | 3,200 |
| 24 | 1.4.4 | Code Integration and testing |  | 15d | 2012-08-22 | 2012-09-11 | 23 | 63d | Software Developer - 1; Software Developer - 2; Software Tester | 360h | 7,200 |
| 25 | 1.4.5 | Fix any errors found during testing |  | 10d | 2012-08-22 | 2012-09-04 | 22, 23 | 0d | Software Developer - 1; Software Developer - 2 | 160h | 3,200 |
| 26 | 1.4.6 | Review and inspection of fixes |  | 5d | 2012-09-05 | 2012-09-11 | 25 | 0d | Customer Care Manager; Software Tester | 80h | 2,400 |
| 27 | 1.4.7 | Implementation sifnoff | milestone | 0d | 2012-09-11 | 2012-09-11 | 26 | 0d | Customer Care Manager |  |  |

| ID | WBS | Task | Type | Duration | Start | Finish | Predecessors | Total slack | Resources | Work | Cost |
| --- | --- | --- | --- | --- | --- | --- | --- | --- | --- | --- | --- |
| 28 | 1.5 | **User Acceptance Testing** |  | 39d | 2012-09-12 | 2012-11-05 |  | 0d |  | 512h | 17,920 |
| 29 | 1.5.1 | Identidy test user groups and create test plan |  | 3d | 2012-09-12 | 2012-09-14 | 27 | 0d | Project Manager | 24h | 960 |
| 30 | 1.5.2 | Communicate test plan to test user groups |  | 2d | 2012-09-17 | 2012-09-18 | 29 | 0d | Project Manager | 16h | 640 |
| 31 | 1.5.3 | System demo to test users |  | 2d | 2012-09-19 | 2012-09-20 | 30 | 0d | Business Analyst | 16h | 480 |
| 32 | 1.5.4 | User pilot phase 1 - 5 users |  | 5d | 2012-09-21 | 2012-09-27 | 31 | 0d | Project Manager; Business Analyst | 80h | 2,800 |
| 33 | 1.5.5 | User pilot phase 2 - 100 users |  | 20d | 2012-09-28 | 2012-10-25 | 32 | 0d | Project Manager; Business Analyst | 320h | 11,200 |
| 34 | 1.5.6 | Retrospective stage - for addressing user queries and fix issues |  | 5d | 2012-10-26 | 2012-11-01 | 33 | 0d | Business Analyst | 40h | 1,200 |
| 35 | 1.5.7 | Take feedback from pilot users to incorporate in user training |  | 2d | 2012-11-02 | 2012-11-05 | 34 | 0d | Project Manager | 16h | 640 |
| 36 | 1.5.8 | User signoff on testing | milestone | 0d | 2012-11-05 | 2012-11-05 | 35 | 0d | Project Sponsor |  |  |
| 37 | 1.6 | **System GoLive** |  | 10d | 2012-11-06 | 2012-11-19 |  | 0d |  | 136h | 3,360 |
| 38 | 1.6.1 | Make system live across company |  | 5d | 2012-11-06 | 2012-11-12 | 36 | 0d | Software Architect; Software Developer - 1 | 80h | 2,000 |
| 39 | 1.6.2 | Review and inspection of installation |  | 3d | 2012-11-13 | 2012-11-15 | 38 | 0d | Software Architect | 24h | 720 |
| 40 | 1.6.3 | Fix any issues during installation |  | 2d | 2012-11-16 | 2012-11-19 | 39 | 0d | Software Developer - 1; Software Developer - 2 | 32h | 640 |
| 41 | 1.6.4 | Signoff | milestone | 0d | 2012-11-19 | 2012-11-19 | 40 | 0d | Software Architect |  |  |
| 42 | 1.7 | **User training and Demo** |  | 9d | 2012-11-20 | 2012-11-30 |  | 0d |  | 152h | 4,560 |
| 43 | 1.7.1 | Draft and provide installation documentation and user manuals |  | 5d | 2012-11-20 | 2012-11-26 | 41 | 9d | Business Analyst | 40h | 1,200 |
| 44 | 1.7.2 | System demo to all users - 1 |  | 2d | 2012-11-20 | 2012-11-21 | 41 | 0d | Business Analyst | 16h | 480 |
| 45 | 1.7.3 | System demo to all users - 2 |  | 2d | 2012-11-22 | 2012-11-23 | 44 | 0d | Business Analyst | 16h | 480 |
| 46 | 1.7.4 | Technical training to technical users |  | 5d | 2012-11-26 | 2012-11-30 | 45 | 0d | Business Analyst; Software Architect | 80h | 2,400 |
| 47 | 1.7.5 | Signoff from users | milestone | 0d | 2012-11-30 | 2012-11-30 | 46 | 5d | Project Sponsor |  |  |
| 48 | 1.8 | **Project Closure and Handover** |  | 5d | 2012-12-03 | 2012-12-07 |  | 0d |  | 56h | 2,240 |
| 49 | 1.8.1 | Prepare thank you note for all stakeholders |  | 2d | 2012-12-03 | 2012-12-04 | 46 | 3d | Project Manager | 16h | 640 |
| 50 | 1.8.2 | Collect feedback from all users |  | 3d | 2012-12-03 | 2012-12-05 | 46 | 0d | Project Manager | 24h | 960 |
| 51 | 1.8.3 | Conduct project closure meeting |  | 1d | 2012-12-06 | 2012-12-06 | 50 | 0d | Project Manager | 8h | 320 |
| 52 | 1.8.4 | Handover system to maintenence team |  | 1d | 2012-12-07 | 2012-12-07 | 51 | 0d | Project Manager | 8h | 320 |
